# نیروگاه خورشیدی یزد- پترو کاویان صنعت پارس

Schedule from MS Project, 2026-01-11 to 2026-09-12.

## Calendars

- Standard: Mon-Sun 08:00-12:00, 13:00-17:00. Exceptions (off unless hours are given): 2026-03-20 to 2026-03-24 (عید نوروز).

## Schedule

| ID | WBS | Task | Type | Duration | Start | Finish | Predecessors | Total slack | Free slack | start shamsi | finish shamsi |
| --- | --- | --- | --- | --- | --- | --- | --- | --- | --- | --- | --- |
| 1 | 1 | شروع | milestone | 0d | 2026-01-11 | 2026-01-11 |  | 0d |  | 1404/10/21 | 1404/10/21 |
| 2 | 2 | **مایلستون های کلیدی** |  | 229d | 2026-01-13 | 2026-09-04 |  | 0d |  | 1404/10/23 | 1405/6/13 |
| 3 | 2.1 | دریافت سایر اطلاعات مقدماتی از کارفرما (آزمایش شیمیایی خاک، تست کشش پایه ها و…) | milestone | 0d | 2026-01-13 | 2026-01-13 | 1FS+3d | 0d |  | 1404/10/23 | 1404/10/23 |
| 4 | 2.2 | واریز اولین پیش پرداخت بخش مهندسی | milestone | 0d | 2026-02-02 | 2026-02-02 | 1FS+23d | 0d |  | 1404/11/13 | 1404/11/13 |
| 5 | 2.3 | دریافت مطالعات ژئوتکنیک | milestone | 0d | 2026-01-13 | 2026-01-13 | 3 | 21d | 14d | 1404/10/23 | 1404/10/23 |
| 6 | 2.4 | تحویل زمین | milestone | 0d | 2026-01-26 | 2026-01-26 | 1FS+16d | 1d | 0d | 1404/11/6 | 1404/11/6 |
| 7 | 2.5 | تاییدیه تجهیزات (پنل، اینورتر و MVStation( | milestone | 0d | 2026-01-22 | 2026-01-22 | 21FS-6d, 22FS-6d, 23FS-6d | 6d | 5d | 1404/11/2 | 1404/11/2 |
| 8 | 2.6 | اتمام طراحی و اخذ تاییدیه | milestone | 0d | 2026-03-08 | 2026-03-08 | 64, 65, 66, 67, 69, 70, 71, 72, 73, 74, 76, 77, 89, 79, 80, 81, 82, 83, 84, 85, 86, 87, 90, 92, 93, 94, 95, 106, 108, 109, 118, 119, 111, 113, 114, 116, 117, 121, 123, 124, 125, 127, 128, 129, 130, 131, 132, 133, 137, 138, 154, 156, 157, 158, 161, 162, 163, 167, 168, 169, 170, 172, 173, 171, 21, 24, 25, 26, 27, 28, 29, 30, 31, 32, 33, 151, 34, 35, 160, 107, 144 | 1d | 0d | 1404/12/17 | 1404/12/17 |
| 9 | 2.7 | اتمام استعلام قیمتی و سفارش گذاری خرید خارجی | milestone | 0d | 2026-02-27 | 2026-02-27 | 254, 260, 266, 272 | 13d | 0d | 1404/12/8 | 1404/12/8 |
| 10 | 2.8 | اتمام تامین و تحویل خرید خارجی در سایت پروژه | milestone | 0d | 2026-07-21 | 2026-07-21 | 258, 264, 270, 276 | 18d | 0d | 1405/4/30 | 1405/4/30 |
| 11 | 2.9 | اتمام تجهیز کارگاه | milestone | 0d | 2026-03-09 | 2026-03-09 | 279, 280, 281 | 0d |  | 1404/12/18 | 1404/12/18 |
| 12 | 2.10 | اتمام نصب سازه | milestone | 0d | 2026-07-19 | 2026-07-19 | 325 | 43d | 33d | 1405/4/28 | 1405/4/28 |
| 13 | 2.11 | اتمام نصب پنل | milestone | 0d | 2026-08-21 | 2026-08-21 | 326 | 10d |  | 1405/5/30 | 1405/5/30 |
| 14 | 2.12 | اتمام ساختمان مانیتورینگ | milestone | 0d | 2026-09-04 | 2026-09-04 | 310 | 0d |  | 1405/6/13 | 1405/6/13 |
| 15 | 2.13 | اتمام نصب MVStaion | milestone | 0d | 2026-07-23 | 2026-07-23 | 338 | 44d | 43d | 1405/5/1 | 1405/5/1 |
| 16 | 2.14 | اتمام نصب اینورتر | milestone | 0d | 2026-07-29 | 2026-07-29 | 329 | 18d | 0d | 1405/5/7 | 1405/5/7 |
| 17 | 2.15 | تست پست بالادست | milestone | 0d | 2026-07-12 | 2026-07-12 | 367 | 58d |  | 1405/4/21 | 1405/4/21 |
| 18 | 3 | **مهندسی** |  | 128d | 2026-01-14 | 2026-05-26 |  | 0d |  | 1404/10/24 | 1405/3/5 |
| 19 | 3.1 | **طراحی و اخذ تاییدیه طراحی پایه** |  | 27d | 2026-01-14 | 2026-02-09 |  | 0d |  | 1404/10/24 | 1404/11/20 |
| 20 | 3.1.1 | **ارایه و اخذ تاییدیه دیتاشیت ها** |  | 23d | 2026-01-18 | 2026-02-09 |  | 0d |  | 1404/10/28 | 1404/11/20 |
| 21 | 3.1.1.1 | Solar Panel Datasheet |  | 10d | 2026-01-18 | 2026-01-27 | 43FS-6d | 0d |  | 1404/10/28 | 1404/11/7 |
| 22 | 3.1.1.2 | Inverter Datasheet |  | 10d | 2026-01-18 | 2026-01-27 | 44FS-6d | 0d |  | 1404/10/28 | 1404/11/7 |
| 23 | 3.1.1.3 | MV Station Datasheet |  | 10d | 2026-01-18 | 2026-01-27 | 45FS-6d | 0d |  | 1404/10/28 | 1404/11/7 |
| 24 | 3.1.1.4 | DC Connection (MC4) Datasheet |  | 10d | 2026-01-18 | 2026-01-27 | 46FS-6d | 0d |  | 1404/10/28 | 1404/11/7 |
| 25 | 3.1.1.5 | DC Cable Datasheet |  | 10d | 2026-01-18 | 2026-01-27 | 47FS-6d | 0d |  | 1404/10/28 | 1404/11/7 |
| 26 | 3.1.1.6 | LV Cable Datasheet |  | 10d | 2026-01-18 | 2026-01-27 | 48FS-6d | 0d |  | 1404/10/28 | 1404/11/7 |
| 27 | 3.1.1.7 | MV Cable Datasheet |  | 10d | 2026-01-18 | 2026-01-27 | 49FS-6d | 0d |  | 1404/10/28 | 1404/11/7 |
| 28 | 3.1.1.8 | MV Switchgear (CT, PT, Relay) Datasheet |  | 10d | 2026-01-18 | 2026-01-27 | 50FS-6d | 0d |  | 1404/10/28 | 1404/11/7 |
| 29 | 3.1.1.9 | Earthing and Lightning Datasheet |  | 10d | 2026-01-18 | 2026-01-27 | 51FS-6d | 0d |  | 1404/10/28 | 1404/11/7 |
| 30 | 3.1.1.10 | Auxiliary Transformer Datasheet |  | 10d | 2026-01-18 | 2026-01-27 | 52FS-6d | 0d |  | 1404/10/28 | 1404/11/7 |
| 31 | 3.1.1.11 | UPS and Battery Datasheet |  | 10d | 2026-01-18 | 2026-01-27 | 53FS-6d | 0d |  | 1404/10/28 | 1404/11/7 |
| 32 | 3.1.1.12 | Diesel Generator Datasheet |  | 10d | 2026-01-18 | 2026-01-27 | 54FS-6d | 0d |  | 1404/10/28 | 1404/11/7 |
| 33 | 3.1.1.13 | Monitoring System Datasheet |  | 10d | 2026-01-18 | 2026-01-27 | 55FS-6d | 0d |  | 1404/10/28 | 1404/11/7 |
| 34 | 3.1.1.14 | Data Logger Datasheet |  | 10d | 2026-01-31 | 2026-02-09 | 56FS-6d | 28d | 27d | 1404/11/11 | 1404/11/20 |
| 35 | 3.1.1.15 | Weather Station Datasheet |  | 10d | 2026-01-31 | 2026-02-09 | 57FS-6d | 28d | 27d | 1404/11/11 | 1404/11/20 |
| 36 | 3.1.1.16 | CCTV and NVR Datasheet |  | 10d | 2026-01-31 | 2026-02-09 | 58FS-6d | 14d | 8d | 1404/11/11 | 1404/11/20 |
| 37 | 3.1.1.17 | HVAC Datasheet |  | 10d | 2026-01-31 | 2026-02-09 | 59FS-6d | 1d | 0d | 1404/11/11 | 1404/11/20 |
| 38 | 3.1.1.18 | Piping Material, Plumbing Fittings, Pumps Datasheet |  | 10d | 2026-01-31 | 2026-02-09 | 60FS-6d | 4d | 0d | 1404/11/11 | 1404/11/20 |
| 39 | 3.1.1.19 | Septic Tank Datasheet |  | 10d | 2026-01-31 | 2026-02-09 | 61FS-6d | 4d | 0d | 1404/11/11 | 1404/11/20 |
| 40 | 3.1.1.20 | Water TankDatasheet |  | 10d | 2026-01-31 | 2026-02-09 | 62FS-6d | 4d | 0d | 1404/11/11 | 1404/11/20 |
| 41 | 3.1.1.21 | Fire Alarm System Datasheet |  | 10d | 2026-01-31 | 2026-02-09 | 63FS-6d | 18d | 15d | 1404/11/11 | 1404/11/20 |

| ID | WBS | Task | Duration | Start | Finish | Predecessors | Total slack | Free slack | start shamsi | finish shamsi |
| --- | --- | --- | --- | --- | --- | --- | --- | --- | --- | --- |
| 42 | 3.1.2 | **ارایه و اخذ تاییدیه مشخصات** | 23d | 2026-01-14 | 2026-02-05 |  | 0d |  | 1404/10/24 | 1404/11/16 |
| 43 | 3.1.2.1 | Solar Panel Technical Specification | 10d | 2026-01-14 | 2026-01-23 | 3 | 0d |  | 1404/10/24 | 1404/11/3 |
| 44 | 3.1.2.2 | Inverter Technical Specification | 10d | 2026-01-14 | 2026-01-23 | 3 | 0d |  | 1404/10/24 | 1404/11/3 |
| 45 | 3.1.2.3 | MV Station Technical Specification | 10d | 2026-01-14 | 2026-01-23 | 3 | 0d |  | 1404/10/24 | 1404/11/3 |
| 46 | 3.1.2.4 | DC Connection (MC4) Technical Specification | 10d | 2026-01-14 | 2026-01-23 | 3 | 0d |  | 1404/10/24 | 1404/11/3 |
| 47 | 3.1.2.5 | DC Cable Technical Specification | 10d | 2026-01-14 | 2026-01-23 | 3 | 0d |  | 1404/10/24 | 1404/11/3 |
| 48 | 3.1.2.6 | LV Cable Technical Specification | 10d | 2026-01-14 | 2026-01-23 | 3 | 0d |  | 1404/10/24 | 1404/11/3 |
| 49 | 3.1.2.7 | MV Cable Technical Specification | 10d | 2026-01-14 | 2026-01-23 | 3 | 0d |  | 1404/10/24 | 1404/11/3 |
| 50 | 3.1.2.8 | MV Switchgear (CT, PT, Relay) Technical Specification | 10d | 2026-01-14 | 2026-01-23 | 3 | 0d |  | 1404/10/24 | 1404/11/3 |
| 51 | 3.1.2.9 | Earthing and Lightning Technical Specification | 10d | 2026-01-14 | 2026-01-23 | 3 | 0d |  | 1404/10/24 | 1404/11/3 |
| 52 | 3.1.2.10 | Auxiliary Transformer Technical Specification | 10d | 2026-01-14 | 2026-01-23 | 3 | 0d |  | 1404/10/24 | 1404/11/3 |
| 53 | 3.1.2.11 | UPS and Battery Technical Specification | 10d | 2026-01-14 | 2026-01-23 | 3 | 0d |  | 1404/10/24 | 1404/11/3 |
| 54 | 3.1.2.12 | Diesel Generator Technical Specification | 10d | 2026-01-14 | 2026-01-23 | 3 | 0d |  | 1404/10/24 | 1404/11/3 |
| 55 | 3.1.2.13 | Monitoring System Technical Specification | 10d | 2026-01-14 | 2026-01-23 | 3 | 0d |  | 1404/10/24 | 1404/11/3 |
| 56 | 3.1.2.14 | Data Logger Technical Specification | 10d | 2026-01-27 | 2026-02-05 | 3, 6, 7 | 28d | 0d | 1404/11/7 | 1404/11/16 |
| 57 | 3.1.2.15 | Weather Station Technical Specification | 10d | 2026-01-27 | 2026-02-05 | 3, 6, 7 | 28d | 0d | 1404/11/7 | 1404/11/16 |
| 58 | 3.1.2.16 | CCTV and NVR Technical Specification | 10d | 2026-01-27 | 2026-02-05 | 3, 6, 7 | 14d | 0d | 1404/11/7 | 1404/11/16 |
| 59 | 3.1.2.17 | HVAC Technical Specification | 10d | 2026-01-27 | 2026-02-05 | 3, 6, 7 | 1d | 0d | 1404/11/7 | 1404/11/16 |
| 60 | 3.1.2.18 | Piping Material, Plumbing Fittings, Pumps Technical Specification | 10d | 2026-01-27 | 2026-02-05 | 3, 6, 7 | 4d | 0d | 1404/11/7 | 1404/11/16 |
| 61 | 3.1.2.19 | Septic Tank Technical Specification | 10d | 2026-01-27 | 2026-02-05 | 3, 6, 7 | 4d | 0d | 1404/11/7 | 1404/11/16 |
| 62 | 3.1.2.20 | Water Tank Technical Specification | 10d | 2026-01-27 | 2026-02-05 | 3, 6, 7 | 4d | 0d | 1404/11/7 | 1404/11/16 |
| 63 | 3.1.2.21 | Fire Alarm System Technical Specification | 10d | 2026-01-27 | 2026-02-05 | 3, 6, 7 | 18d | 0d | 1404/11/7 | 1404/11/16 |
| 64 | 3.1.3 | ارایه و اخذ تاییدیه PVSYST Report | 10d | 2026-01-22 | 2026-01-31 | 21FS-6d, 22FS-6d, 23FS-6d, 24FS-6d, 25FS-6d, 26FS-6d, 27FS-6d, 33FS-6d, 32FS-6d, 31FS-6d, 30FS-6d, 29FS-6d, 28FS-6d | 0d |  | 1404/11/2 | 1404/11/11 |
| 65 | 3.1.4 | ارایه و اخذ تاییدیه General layout | 9d | 2026-01-22 | 2026-01-30 | 64SS | 0d |  | 1404/11/2 | 1404/11/10 |
| 66 | 3.1.5 | ارایه و اخذ تاییدیه General Single Line Diagram (GSLD) | 10d | 2026-01-25 | 2026-02-03 | 65FS-6d | 6d | 0d | 1404/11/5 | 1404/11/14 |
| 67 | 3.1.6 | ارایه و اخذ تاییدیه Plant Detailed Report | 10d | 2026-01-26 | 2026-02-04 | 64FS-6d | 8d | 0d | 1404/11/6 | 1404/11/15 |

| ID | WBS | Task | Duration | Start | Finish | Predecessors | Total slack | Free slack | start shamsi | finish shamsi |
| --- | --- | --- | --- | --- | --- | --- | --- | --- | --- | --- |
| 68 | 3.2 | **طراحی و اخذ تاییدیه عمرانی مطابق MDL ارایه شده** | 39d | 2026-01-28 | 2026-03-07 |  | 3d |  | 1404/11/8 | 1404/12/16 |
| 69 | 3.2.1 | Topography of Field | 10d | 2026-02-03 | 2026-02-12 | 3, 6, 4 | 6d | 0d | 1404/11/14 | 1404/11/23 |
| 70 | 3.2.2 | Geotechnical Test Report | 10d | 2026-02-03 | 2026-02-12 | 3, 4 | 11d | 0d | 1404/11/14 | 1404/11/23 |
| 71 | 3.2.3 | Ramming and Pull-Out Test Report | 10d | 2026-02-03 | 2026-02-12 | 3, 4 | 0d |  | 1404/11/14 | 1404/11/23 |
| 72 | 3.2.4 | Hydrology Study Report | 10d | 2026-02-03 | 2026-02-12 | 3, 4 | 12d | 0d | 1404/11/14 | 1404/11/23 |
| 73 | 3.2.5 | Site Fence Detail Drawing | 10d | 2026-02-18 | 2026-02-27 | 103FS-5d | 6d | 0d | 1404/11/29 | 1404/12/8 |
| 74 | 3.2.6 | Logistic Area | 10d | 2026-01-31 | 2026-02-09 | 65 | 18d | 0d | 1404/11/11 | 1404/11/20 |
| 75 | 3.2.7 | Buildings Foundation & Structure Calculation | 10d | 2026-02-03 | 2026-02-12 | 5, 3, 4 | 1d | 0d | 1404/11/14 | 1404/11/23 |
| 76 | 3.2.8 | Buildings Foundation & Structure Drawing | 10d | 2026-02-08 | 2026-02-17 | 75FS-5d | 1d | 0d | 1404/11/19 | 1404/11/28 |
| 77 | 3.2.9 | Parking Foundation & Structure Detail Drawing | 10d | 2026-02-03 | 2026-02-12 | 5, 3, 4 | 25d | 24d | 1404/11/14 | 1404/11/23 |
| 78 | 3.2.10 | Power Plant Entrance Gate Drawing | 10d | 2026-02-22 | 2026-03-03 | 3, 73FS-6d, 4 | 23d | 0d | 1404/12/3 | 1404/12/12 |
| 79 | 3.2.11 | Parking Architectural Drawing | 10d | 2026-02-10 | 2026-02-19 | 74, 65 | 18d | 17d | 1404/11/21 | 1404/11/30 |
| 80 | 3.2.12 | Landscaping Layout | 9d | 2026-01-31 | 2026-02-08 | 65 | 0d |  | 1404/11/11 | 1404/11/19 |
| 81 | 3.2.13 | Buildings Architectural Detail drawing | 10d | 2026-02-12 | 2026-02-21 | 76FS-6d | 1d | 0d | 1404/11/23 | 1404/12/2 |
| 82 | 3.2.14 | Fence MTO | 9d | 2026-02-22 | 2026-03-02 | 73FS-6d | 6d | 0d | 1404/12/3 | 1404/12/11 |
| 83 | 3.2.15 | Site Grading and Leveling | 10d | 2026-02-13 | 2026-02-22 | 69, 3, 70, 4 | 15d | 14d | 1404/11/24 | 1404/12/3 |
| 84 | 3.2.16 | Drainage For Insite of Plant & Implementation Detail Drawing | 9d | 2026-02-13 | 2026-02-21 | 72, 65 | 12d | 0d | 1404/11/24 | 1404/12/2 |
| 85 | 3.2.17 | Flood Managmant For Outsite of Plant & Implementation Detail Drawing | 10d | 2026-02-16 | 2026-02-25 | 5FS-6d, 72FS-6d, 84FS-6d | 12d | 11d | 1404/11/27 | 1404/12/6 |
| 86 | 3.2.18 | Internal Road Layout & Implementation Detail Drawing | 10d | 2026-01-31 | 2026-02-09 | 65 | 20d | 0d | 1404/11/11 | 1404/11/20 |
| 87 | 3.2.19 | Access Road Layout & Implementation Detail Drawing | 10d | 2026-01-31 | 2026-02-09 | 65 | 20d | 0d | 1404/11/11 | 1404/11/20 |
| 88 | 3.2.20 | MV Station Foundation Calculation | 10d | 2026-01-28 | 2026-02-06 | 5, 7, 23 | 26d | 0d | 1404/11/8 | 1404/11/17 |
| 89 | 3.2.21 | MV Station Foundation Drawings | 10d | 2026-02-02 | 2026-02-11 | 88FS-5d | 26d | 25d | 1404/11/13 | 1404/11/22 |
| 90 | 3.2.22 | Auxiliary Transformer Foundation Detail Drawings | 10d | 2026-01-28 | 2026-02-06 | 30 | 31d | 30d | 1404/11/8 | 1404/11/17 |
| 91 | 3.2.23 | Calculation Report for Structure | 10d | 2026-02-07 | 2026-02-16 | 3, 65FS-6d, 71FS-6d, 4 | 0d |  | 1404/11/18 | 1404/11/27 |
| 92 | 3.2.24 | Structure Detail Drawings | 10d | 2026-02-13 | 2026-02-22 | 91FS-4d | 0d |  | 1404/11/24 | 1404/12/3 |
| 93 | 3.2.25 | PV Structure Ramming Location Details Drawing (Stacking) | 10d | 2026-02-07 | 2026-02-16 | 65FS-6d, 69FS-6d, 70FS-6d | 12d | 0d | 1404/11/18 | 1404/11/27 |
| 94 | 3.2.26 | Solar Module Structure MTO | 10d | 2026-02-17 | 2026-02-26 | 92FS-6d, 65FS-6d | 11d | 10d | 1404/11/28 | 1404/12/7 |
| 95 | 3.2.27 | Table UTM Point | 9d | 2026-02-17 | 2026-02-25 | 93 | 12d | 11d | 1404/11/28 | 1404/12/6 |
| 96 | 3.2.28 | Structure, Entrance Gate and Foundation of Building MTO | 10d | 2026-02-26 | 2026-03-07 | 78FS-6d, 76FS-6d, 81FS-6d | 23d | 0d | 1404/12/7 | 1404/12/16 |
| 97 | 3.2.29 | System Drainage Calculation | 10d | 2026-02-13 | 2026-02-22 | 3, 70, 4, 21 | 11d | 0d | 1404/11/24 | 1404/12/3 |
| 98 | 3.2.30 | Lighting Foundation Calculation | 5d | 2026-01-31 | 2026-02-04 | 65 | 6d | 0d | 1404/11/11 | 1404/11/15 |
| 99 | 3.2.31 | Lightning Foundation Drawing | 5d | 2026-02-05 | 2026-02-09 | 98, 100 | 6d | 0d | 1404/11/16 | 1404/11/20 |
| 100 | 3.2.32 | Lighting and CCTV Pole Calculation | 5d | 2026-01-31 | 2026-02-04 | 65 | 6d | 0d | 1404/11/11 | 1404/11/15 |
| 101 | 3.2.33 | Septic Tank Detail Drawing | 5d | 2026-02-10 | 2026-02-14 | 80, 39, 40, 38 | 4d |  | 1404/11/21 | 1404/11/25 |
| 102 | 3.2.34 | Water Tank Foundation Detail Drawing | 10d | 2026-02-09 | 2026-02-18 | 80 | 0d |  | 1404/11/20 | 1404/11/29 |
| 103 | 3.2.35 | Calculation for Fence | 10d | 2026-02-13 | 2026-02-22 | 3, 69, 4 | 6d | 0d | 1404/11/24 | 1404/12/3 |
| 104 | 3.2.36 | Material Requisition for Fence | 1d | 2026-03-03 | 2026-03-03 | 82 | 6d | 0d | 1404/12/12 | 1404/12/12 |

| ID | WBS | Task | Duration | Start | Finish | Predecessors | Total slack | Free slack | start shamsi | finish shamsi |
| --- | --- | --- | --- | --- | --- | --- | --- | --- | --- | --- |
| 105 | 3.3 | **طراحی و اخذ تاییدیه الکتریکال مطابق MDL ارایه شده** | 114d | 2026-01-28 | 2026-05-26 |  | 5d |  | 1404/11/8 | 1405/3/5 |
| 106 | 3.3.1 | Solar Module, Connector, Inverter and MV station MTO | 10d | 2026-02-05 | 2026-02-14 | 64, 65, 67, 66 | 8d | 0d | 1404/11/16 | 1404/11/25 |
| 107 | 3.3.2 | PV System Calculation Study (String Size, Optimum Tilt and Pitch) | 10d | 2026-02-01 | 2026-02-10 | 64 | 27d | 26d | 1404/11/12 | 1404/11/21 |
| 108 | 3.3.3 | Strings Connection Diagram & Inverter Arrangement (DC Side) | 10d | 2026-02-04 | 2026-02-13 | 65, 66 | 11d | 0d | 1404/11/15 | 1404/11/24 |
| 109 | 3.3.4 | Module & Table Arrangement (DC Side) | 10d | 2026-01-31 | 2026-02-09 | 65 | 15d | 4d | 1404/11/11 | 1404/11/20 |
| 110 | 3.3.5 | DC Cable Calculation | 10d | 2026-02-14 | 2026-02-23 | 108, 109, 118, 119 | 11d | 0d | 1404/11/25 | 1404/12/4 |
| 111 | 3.3.6 | DC Cable List, Labeling Code and MTO | 9d | 2026-02-18 | 2026-02-26 | 110FS-6d | 11d | 10d | 1404/11/29 | 1404/12/7 |
| 112 | 3.3.7 | LVAC Cable Calculation | 5d | 2026-02-10 | 2026-02-14 | 118, 119 | 10d | 0d | 1404/11/21 | 1404/11/25 |
| 113 | 3.3.8 | LV Cable Termination List and MTO | 9d | 2026-02-15 | 2026-02-23 | 112 | 10d | 0d | 1404/11/26 | 1404/12/4 |
| 114 | 3.3.9 | LV Cable List, Labeling Code and MTO | 4d | 2026-02-24 | 2026-02-27 | 113 | 10d | 9d | 1404/12/5 | 1404/12/8 |
| 115 | 3.3.10 | MV Cable Calculations | 5d | 2026-02-10 | 2026-02-14 | 118, 119 | 5d | 0d | 1404/11/21 | 1404/11/25 |
| 116 | 3.3.11 | MV Cable List, Labeling Code and MTO | 9d | 2026-02-15 | 2026-02-23 | 115 | 5d | 0d | 1404/11/26 | 1404/12/4 |
| 117 | 3.3.12 | MV Cable Termination List and MTO | 9d | 2026-02-24 | 2026-03-04 | 116 | 5d | 4d | 1404/12/5 | 1404/12/13 |
| 118 | 3.3.13 | Electrical Cable Route and Section | 10d | 2026-01-31 | 2026-02-09 | 65 | 5d | 0d | 1404/11/11 | 1404/11/20 |
| 119 | 3.3.14 | Cable Trench Layout | 10d | 2026-01-31 | 2026-02-09 | 65 | 5d | 0d | 1404/11/11 | 1404/11/20 |
| 120 | 3.3.15 | Earthing System Calculation | 5d | 2026-02-10 | 2026-02-14 | 118, 119 | 13d | 0d | 1404/11/21 | 1404/11/25 |
| 121 | 3.3.16 | Earthing System Layout | 10d | 2026-02-15 | 2026-02-24 | 120 | 13d | 12d | 1404/11/26 | 1404/12/5 |
| 122 | 3.3.17 | Lightning Protection Calculation | 5d | 2026-01-31 | 2026-02-04 | 65 | 13d | 0d | 1404/11/11 | 1404/11/15 |
| 123 | 3.3.18 | Lightning Protection Layout | 10d | 2026-02-05 | 2026-02-14 | 122 | 13d | 0d | 1404/11/16 | 1404/11/25 |
| 124 | 3.3.19 | Earthing and Lightning Protection MTO | 10d | 2026-02-15 | 2026-02-24 | 123 | 13d | 12d | 1404/11/26 | 1404/12/5 |
| 125 | 3.3.20 | Protection Single Line Diagram (PSLD) | 10d | 2026-02-04 | 2026-02-13 | 66 | 24d | 23d | 1404/11/15 | 1404/11/24 |
| 126 | 3.3.21 | CT and PT Calculations | 5d | 2026-02-04 | 2026-02-08 | 7, 66 | 6d | 0d | 1404/11/15 | 1404/11/19 |
| 127 | 3.3.22 | MV Switchgear Logic Diagram | 10d | 2026-02-09 | 2026-02-18 | 126 | 6d | 0d | 1404/11/20 | 1404/11/29 |
| 128 | 3.3.23 | Trip Table | 10d | 2026-02-19 | 2026-02-28 | 127 | 9d | 8d | 1404/11/30 | 1404/12/9 |
| 129 | 3.3.24 | Alarm List | 10d | 2026-02-19 | 2026-02-28 | 127 | 9d | 8d | 1404/11/30 | 1404/12/9 |
| 130 | 3.3.25 | Indoor and Outdoor Electrical Plan & Details for Building | 10d | 2026-01-31 | 2026-02-09 | 65 | 28d | 27d | 1404/11/11 | 1404/11/20 |
| 131 | 3.3.26 | MV Switchgear MTO | 10d | 2026-02-14 | 2026-02-23 | 7, 66, 23, 28, 142 | 14d | 13d | 1404/11/25 | 1404/12/4 |
| 132 | 3.3.27 | Load List | 9d | 2026-02-28 | 2026-03-08 | 137, 138, 156, 157, 162, 168, 169, 172, 64, 67 | 1d | 0d | 1404/12/9 | 1404/12/17 |
| 133 | 3.3.28 | LVAC Auxiliary Panel Single Line Diagram | 10d | 2026-01-28 | 2026-02-06 | 26, 27 | 6d | 0d | 1404/11/8 | 1404/11/17 |
| 134 | 3.3.29 | UPS Calculation | 5d | 2026-02-07 | 2026-02-11 | 133, 64, 67 | 6d | 0d | 1404/11/18 | 1404/11/22 |
| 135 | 3.3.30 | AUX Equipment MTO (AUX Transformer, Diesel, UPS, Battery, …) | 10d | 2026-02-12 | 2026-02-21 | 134 | 6d | 0d | 1404/11/23 | 1404/12/2 |
| 136 | 3.3.31 | Indoor and Outdoor Lighting Calculation | 5d | 2026-01-31 | 2026-02-04 | 65 | 2d | 0d | 1404/11/11 | 1404/11/15 |
| 137 | 3.3.32 | Outdoor Lighting Pole Drawing | 9d | 2026-02-05 | 2026-02-13 | 136 | 2d | 0d | 1404/11/16 | 1404/11/24 |
| 138 | 3.3.33 | Outdoor Lighting Layout and Switchboard | 9d | 2026-02-14 | 2026-02-22 | 137 | 2d | 0d | 1404/11/25 | 1404/12/3 |
| 139 | 3.3.34 | Lighting System MTO | 9d | 2026-02-23 | 2026-03-03 | 137, 138 | 2d | 0d | 1404/12/4 | 1404/12/12 |
| 140 | 3.3.35 | Special Tools | 10d | 2026-05-17 | 2026-05-26 | 233, 255, 261, 267, 273 | 109d |  | 1405/2/27 | 1405/3/5 |
| 141 | 3.3.36 | MV Switchgear Schematic Diagram | 5d | 2026-02-04 | 2026-02-08 | 7, 66 | 14d | 0d | 1404/11/15 | 1404/11/19 |
| 142 | 3.3.37 | MV Switchgear Front View Drawing | 5d | 2026-02-09 | 2026-02-13 | 141 | 14d | 0d | 1404/11/20 | 1404/11/24 |
| 143 | 3.3.38 | Material Requisition for Indoor Power and Lighting Distribution Panel | 5d | 2026-02-23 | 2026-02-27 | 137, 138 | 6d | 4d | 1404/12/4 | 1404/12/8 |
| 144 | 3.3.39 | Material Requisition for Auxiliary Transformer | 10d | 2026-02-22 | 2026-03-03 | 135 | 6d | 0d | 1404/12/3 | 1404/12/12 |
| 145 | 3.3.40 | Material Requisition for PCC | 10d | 2026-03-09 | 2026-03-18 | 132 | 80d | 0d | 1404/12/18 | 1404/12/27 |
| 146 | 3.3.41 | Material Requisition for MV Switchgear (CT, PT, Relay) | 10d | 2026-03-09 | 2026-03-18 | 66, 132, 151 | 137d | 5d | 1404/12/18 | 1404/12/27 |
| 147 | 3.3.42 | Material Requisition for AC Cable | 10d | 2026-03-09 | 2026-03-18 | 113, 117, 8 | 96d | 0d | 1404/12/18 | 1404/12/27 |
| 148 | 3.3.43 | Material Requisition for DC Cable | 10d | 2026-03-09 | 2026-03-18 | 111, 8 | 131d | 0d | 1404/12/18 | 1404/12/27 |
| 149 | 3.3.44 | Material Requisition for Earthing and Lightning | 10d | 2026-03-09 | 2026-03-18 | 124, 8 | 104d | 0d | 1404/12/18 | 1404/12/27 |
| 150 | 3.3.45 | Material Requisition for DC Connection (MC4) | 10d | 2026-03-09 | 2026-03-18 | 131, 137, 8 | 127d | 0d | 1404/12/18 | 1404/12/27 |
| 151 | 3.3.46 | Material Requisition for Lighting System | 8d | 2026-02-28 | 2026-03-07 | 139FS-4d, 143FS-4d | 2d | 0d | 1404/12/9 | 1404/12/16 |
| 152 | 3.3.47 | Material Requisition for UPS and Battery | 10d | 2026-03-04 | 2026-03-13 | 144 | 132d | 0d | 1404/12/13 | 1404/12/22 |

| ID | WBS | Task | Duration | Start | Finish | Predecessors | Total slack | Free slack | start shamsi | finish shamsi |
| --- | --- | --- | --- | --- | --- | --- | --- | --- | --- | --- |
| 153 | 3.4 | **طراحی و اخذ تاییدیه مکانیکال مطابق MDL ارایه شده** | 18d | 2026-02-10 | 2026-02-27 |  | 1d |  | 1404/11/21 | 1404/12/8 |
| 154 | 3.4.1 | Solar Panel Cleaning & Maintenance Procedures | 4d | 2026-02-23 | 2026-02-26 | 97 | 11d | 10d | 1404/12/4 | 1404/12/7 |
| 155 | 3.4.2 | HVAC Equipment Calculation | 10d | 2026-02-10 | 2026-02-19 | 37 | 1d | 0d | 1404/11/21 | 1404/11/30 |
| 156 | 3.4.3 | HVAC Equipment Layout for Building | 4d | 2026-02-20 | 2026-02-23 | 81FS-6d, 155 | 1d | 0d | 1404/12/1 | 1404/12/4 |
| 157 | 3.4.4 | HVAC and Piping System MTO | 4d | 2026-02-24 | 2026-02-27 | 156 | 1d | 0d | 1404/12/5 | 1404/12/8 |
| 158 | 3.4.5 | Mechanical Drawing (Water Supply and Sewage Systems) | 4d | 2026-02-10 | 2026-02-13 | 74, 65 | 24d | 23d | 1404/11/21 | 1404/11/24 |
| 159 | 3.5 | **طراحی و اخذ تاییدیه ایمنی مطابق MDL ارایه شده** | 29d | 2026-02-16 | 2026-03-16 |  | 1d |  | 1404/11/27 | 1404/12/25 |
| 160 | 3.5.1 | Fire Fighting Equipment Arrangement of MV Switchgear Buildings | 8d | 2026-02-16 | 2026-02-23 | 81FS-6d | 1d | 0d | 1404/11/27 | 1404/12/4 |
| 161 | 3.5.2 | Outdoor Fire Fighting Equipment & Shelter Arrangement | 9d | 2026-02-20 | 2026-02-28 | 160FS-4d | 3d | 0d | 1404/12/1 | 1404/12/9 |
| 162 | 3.5.3 | Fire Alarm System Layout and Block Diagram | 8d | 2026-02-20 | 2026-02-27 | 160FS-4d | 1d | 0d | 1404/12/1 | 1404/12/8 |
| 163 | 3.5.4 | Fire and Safety and F & G System MTO | 10d | 2026-02-25 | 2026-03-06 | 161FS-4d, 41 | 3d | 0d | 1404/12/6 | 1404/12/15 |
| 164 | 3.5.5 | Material Requisition for Fire Alarm System | 10d | 2026-02-28 | 2026-03-09 | 162 | 156d | 0d | 1404/12/9 | 1404/12/18 |
| 165 | 3.5.6 | Material Requisition for Fire Fighting Equipment Arrangement | 10d | 2026-03-07 | 2026-03-16 | 163 | 137d | 0d | 1404/12/16 | 1404/12/25 |
| 166 | 3.6 | **طراحی و اخذ تاییدیه ارتباطی مطابق MDL ارایه شده** | 38d | 2026-02-04 | 2026-03-13 |  | 12d |  | 1404/11/15 | 1404/12/22 |
| 167 | 3.6.1 | CCTV System Block Diagram | 4d | 2026-02-10 | 2026-02-13 | 99 | 6d | 0d | 1404/11/21 | 1404/11/24 |
| 168 | 3.6.2 | CCTV System Arrangement & Layout | 4d | 2026-02-14 | 2026-02-17 | 167 | 6d | 0d | 1404/11/25 | 1404/11/28 |
| 169 | 3.6.3 | CCTV Pole Detail Drawing, Switchboard, CAFU Details | 4d | 2026-02-18 | 2026-02-21 | 168, 36 | 6d | 0d | 1404/11/29 | 1404/12/2 |
| 170 | 3.6.4 | CCTV System MTO | 10d | 2026-02-22 | 2026-03-03 | 169 | 6d | 0d | 1404/12/3 | 1404/12/12 |
| 171 | 3.6.5 | SCADA System I/O | 4d | 2026-02-04 | 2026-02-07 | 7, 66 | 30d | 29d | 1404/11/15 | 1404/11/18 |
| 172 | 3.6.6 | Monitoring System Overall Diagram | 4d | 2026-02-19 | 2026-02-22 | 118, 127, 7, 33 | 6d | 0d | 1404/11/30 | 1404/12/3 |
| 173 | 3.6.7 | Telecommunication and Monitoring System MTO | 4d | 2026-02-23 | 2026-02-26 | 172 | 11d | 10d | 1404/12/4 | 1404/12/7 |
| 174 | 3.6.8 | Material Requisition forTelecommunication and Monitoring Cable | 5d | 2026-03-09 | 2026-03-13 | 171, 173, 176 | 150d | 0d | 1404/12/18 | 1404/12/22 |
| 175 | 3.6.9 | Material Requisition forFiber Optics | 5d | 2026-03-09 | 2026-03-13 | 171, 172, 176 | 112d | 0d | 1404/12/18 | 1404/12/22 |
| 176 | 3.6.10 | Material Requisition for CCTV and NVR | 5d | 2026-03-04 | 2026-03-08 | 170 | 85d | 0d | 1404/12/13 | 1404/12/17 |

| ID | WBS | Task | Duration | Start | Finish | Predecessors | Total slack | Free slack | start shamsi | finish shamsi |
| --- | --- | --- | --- | --- | --- | --- | --- | --- | --- | --- |
| 177 | 4 | **تامین و حمل کالا تجهیزات** | 171d | 2026-01-27 | 2026-07-21 |  | 22d |  | 1404/11/7 | 1405/4/30 |
| 178 | 4.1 | **خرید و حمل داخلی** | 139d | 2026-01-27 | 2026-06-19 |  | 22d |  | 1404/11/7 | 1405/3/29 |
| 179 | 4.1.1 | **فنس پیرامونی** | 20d | 2026-03-04 | 2026-03-28 |  | 6d |  | 1404/12/13 | 1405/1/8 |
| 180 | 4.1.1.1 | استعلام قیمت فنس پیرامونی | 3d | 2026-03-04 | 2026-03-06 | 82, 104 | 6d | 0d | 1404/12/13 | 1404/12/15 |
| 181 | 4.1.1.2 | خرید فنس پیرامونی | 10d | 2026-03-07 | 2026-03-16 | 180 | 6d | 0d | 1404/12/16 | 1404/12/25 |
| 182 | 4.1.1.3 | حمل فنس پیرامونی | 7d | 2026-03-17 | 2026-03-28 | 181 | 6d |  | 1404/12/26 | 1405/1/8 |
| 183 | 4.1.2 | **تابلو های توزیع داخلی و روشنایی** | 28d | 2026-03-09 | 2026-04-10 |  | 147d |  | 1404/12/18 | 1405/1/21 |
| 184 | 4.1.2.1 | استعلام قیمت تابلو های توزیع داخلی و روشنایی | 1d | 2026-03-09 | 2026-03-09 | 66, 132, 151 | 147d | 0d | 1404/12/18 | 1404/12/18 |
| 185 | 4.1.2.2 | ساخت تابلو های توزیع داخلی و روشنایی | 20d | 2026-03-10 | 2026-04-03 | 184 | 147d | 0d | 1404/12/19 | 1405/1/14 |
| 186 | 4.1.2.3 | حمل تابلو های توزیع داخلی و روشنایی | 7d | 2026-04-04 | 2026-04-10 | 185 | 147d | 119d | 1405/1/15 | 1405/1/21 |
| 187 | 4.1.3 | **ترانسفورماتور های مصرف داخلی و دیزل ژنراتور** | 30d | 2026-03-04 | 2026-04-07 |  | 150d |  | 1404/12/13 | 1405/1/18 |
| 188 | 4.1.3.1 | استعلام قیمت ترانسفورماتور های مصرف داخلی و دیزل ژنراتور | 3d | 2026-03-04 | 2026-03-06 | 144 | 150d | 0d | 1404/12/13 | 1404/12/15 |
| 189 | 4.1.3.2 | خرید ترانسفورماتور های مصرف داخلی و دیزل ژنراتور | 25d | 2026-03-07 | 2026-04-05 | 188 | 150d | 0d | 1404/12/16 | 1405/1/16 |
| 190 | 4.1.3.3 | حمل ترانسفورماتور های مصرف داخلی و دیزل ژنراتور | 7d | 2026-04-01 | 2026-04-07 | 189FS-5d | 150d |  | 1405/1/12 | 1405/1/18 |
| 191 | 4.1.4 | **تابلوهای پست سوییچگیر** | 80d | 2026-03-19 | 2026-06-11 |  | 80d |  | 1404/12/28 | 1405/3/21 |
| 192 | 4.1.4.1 | استعلام قیمت تابلوهای پست سوییچگیر | 5d | 2026-03-19 | 2026-03-28 | 127, 145 | 80d | 0d | 1404/12/28 | 1405/1/8 |
| 193 | 4.1.4.2 | ساخت تابلوهای پست سوییچگیر | 60d | 2026-03-29 | 2026-05-27 | 192 | 80d | 0d | 1405/1/9 | 1405/3/6 |
| 194 | 4.1.4.3 | حمل تابلوهای پست سوییچگیر | 15d | 2026-05-28 | 2026-06-11 | 193 | 80d | 57d | 1405/3/7 | 1405/3/21 |
| 195 | 4.1.5 | **ct& pt** | 28d | 2026-03-29 | 2026-04-25 |  | 132d |  | 1405/1/9 | 1405/2/5 |
| 196 | 4.1.5.1 | استعلام قیمت ct& pt | 1d | 2026-03-29 | 2026-03-29 | 146, 220 | 132d | 0d | 1405/1/9 | 1405/1/9 |
| 197 | 4.1.5.2 | خرید ct& pt | 20d | 2026-03-30 | 2026-04-18 | 196 | 132d | 0d | 1405/1/10 | 1405/1/29 |
| 198 | 4.1.5.3 | حمل ct& pt | 7d | 2026-04-19 | 2026-04-25 | 197 | 132d | 104d | 1405/1/30 | 1405/2/5 |
| 199 | 4.1.6 | **AC/LV و AC/MV کابل های** | 50d | 2026-03-19 | 2026-05-12 |  | 96d |  | 1404/12/28 | 1405/2/22 |
| 200 | 4.1.6.1 | AC/LV و AC/MV استعلام قیمت کابل های | 7d | 2026-03-19 | 2026-03-30 | 147 | 96d | 0d | 1404/12/28 | 1405/1/10 |
| 201 | 4.1.6.2 | AC/LV و AC/MV خرید کابل های | 36d | 2026-03-31 | 2026-05-05 | 200 | 96d | 0d | 1405/1/11 | 1405/2/15 |
| 202 | 4.1.6.3 | AC/LV و AC/MV حمل کابل های | 10d | 2026-05-03 | 2026-05-12 | 201FS-3d | 96d | 54d | 1405/2/13 | 1405/2/22 |

| ID | WBS | Task | Duration | Start | Finish | Predecessors | Total slack | Free slack | start shamsi | finish shamsi |
| --- | --- | --- | --- | --- | --- | --- | --- | --- | --- | --- |
| 203 | 4.1.7 | **DC کابل های** | 20d | 2026-03-19 | 2026-04-12 |  | 131d |  | 1404/12/28 | 1405/1/23 |
| 204 | 4.1.7.1 | DC استعلام قیمت کابل های | 3d | 2026-03-19 | 2026-03-26 | 148 | 131d | 0d | 1404/12/28 | 1405/1/6 |
| 205 | 4.1.7.2 | DC خرید کابل های | 10d | 2026-03-27 | 2026-04-05 | 204 | 131d | 0d | 1405/1/7 | 1405/1/16 |
| 206 | 4.1.7.3 | DC حمل کابل های | 7d | 2026-04-06 | 2026-04-12 | 205 | 131d |  | 1405/1/17 | 1405/1/23 |
| 207 | 4.1.8 | **کابل های ارتباطی** | 20d | 2026-03-14 | 2026-04-07 |  | 150d |  | 1404/12/23 | 1405/1/18 |
| 208 | 4.1.8.1 | استعلام قیمت کابل های ارتباطی | 3d | 2026-03-14 | 2026-03-16 | 174 | 150d | 0d | 1404/12/23 | 1404/12/25 |
| 209 | 4.1.8.2 | خرید کابل های ارتباطی | 10d | 2026-03-17 | 2026-03-31 | 208 | 150d | 0d | 1404/12/26 | 1405/1/11 |
| 210 | 4.1.8.3 | حمل کابل های ارتباطی | 7d | 2026-04-01 | 2026-04-07 | 209 | 150d | 92d | 1405/1/12 | 1405/1/18 |
| 211 | 4.1.9 | **Fiber Optics (انتقال دیتا داخلی نیروگاه)** | 50d | 2026-03-14 | 2026-05-07 |  | 112d |  | 1404/12/23 | 1405/2/17 |
| 212 | 4.1.9.1 | Fiber Optics استعلام قیمت (انتقال دیتا داخلی نیروگاه) | 10d | 2026-03-14 | 2026-03-28 | 175 | 112d | 0d | 1404/12/23 | 1405/1/8 |
| 213 | 4.1.9.2 | Fiber Optics خرید (انتقال دیتا داخلی نیروگاه) | 30d | 2026-03-29 | 2026-04-27 | 212 | 112d | 0d | 1405/1/9 | 1405/2/7 |
| 214 | 4.1.9.3 | Fiber Optics حمل (انتقال دیتا داخلی نیروگاه) | 10d | 2026-04-28 | 2026-05-07 | 213 | 112d | 54d | 1405/2/8 | 1405/2/17 |
| 215 | 4.1.10 | **کابل سیستم زمین و تجهیزات جانبی (ارت)** | 42d | 2026-03-19 | 2026-05-04 |  | 104d |  | 1404/12/28 | 1405/2/14 |
| 216 | 4.1.10.1 | استعلام قیمت کابل سیستم زمین و تجهیزات جانبی (ارت) | 5d | 2026-03-19 | 2026-03-28 | 149 | 104d | 0d | 1404/12/28 | 1405/1/8 |
| 217 | 4.1.10.2 | خرید کابل سیستم زمین و تجهیزات جانبی (ارت) | 30d | 2026-03-29 | 2026-04-27 | 216 | 104d | 0d | 1405/1/9 | 1405/2/7 |
| 218 | 4.1.10.3 | حمل کابل سیستم زمین و تجهیزات جانبی (ارت) | 7d | 2026-04-28 | 2026-05-04 | 217 | 104d | 57d | 1405/2/8 | 1405/2/14 |
| 219 | 4.1.11 | **MC4** | 32d | 2026-03-19 | 2026-04-24 |  | 127d |  | 1404/12/28 | 1405/2/4 |
| 220 | 4.1.11.1 | MC4 استعلام قیمت | 5d | 2026-03-19 | 2026-03-28 | 150 | 127d | 0d | 1404/12/28 | 1405/1/8 |
| 221 | 4.1.11.2 | MC4 خرید | 20d | 2026-03-29 | 2026-04-17 | 220 | 127d | 0d | 1405/1/9 | 1405/1/28 |
| 222 | 4.1.11.3 | MC4 حمل | 7d | 2026-04-18 | 2026-04-24 | 221 | 127d | 119d | 1405/1/29 | 1405/2/4 |
| 223 | 4.1.12 | **و تجهیزات جانبیCCTV سیستم** | 52d | 2026-03-04 | 2026-04-29 |  | 121d |  | 1404/12/13 | 1405/2/9 |
| 224 | 4.1.12.1 | و تجهیزات جانبیCCTV استعلام قیمت سیستم | 7d | 2026-03-04 | 2026-03-10 | 170 | 121d | 0d | 1404/12/13 | 1404/12/19 |
| 225 | 4.1.12.2 | و تجهیزات جانبیCCTV خرید سیستم | 35d | 2026-03-11 | 2026-04-19 | 224 | 121d | 0d | 1404/12/20 | 1405/1/30 |
| 226 | 4.1.12.3 | و تجهیزات جانبیCCTV حمل سیستم | 10d | 2026-04-20 | 2026-04-29 | 225 | 121d | 62d | 1405/1/31 | 1405/2/9 |

| ID | WBS | Task | Duration | Start | Finish | Predecessors | Total slack | Free slack | start shamsi | finish shamsi |
| --- | --- | --- | --- | --- | --- | --- | --- | --- | --- | --- |
| 227 | 4.1.13 | **تجهیزات سیستم روشنایی** | 55d | 2026-03-08 | 2026-05-06 |  | 110d |  | 1404/12/17 | 1405/2/16 |
| 228 | 4.1.13.1 | استعلام قیمت تجهیزات سیستم روشنایی | 5d | 2026-03-08 | 2026-03-12 | 151 | 110d | 0d | 1404/12/17 | 1404/12/21 |
| 229 | 4.1.13.2 | خرید تجهیزات سیستم روشنایی | 40d | 2026-03-13 | 2026-04-26 | 228 | 110d | 0d | 1404/12/22 | 1405/2/6 |
| 230 | 4.1.13.3 | حمل تجهیزات سیستم روشنایی | 10d | 2026-04-27 | 2026-05-06 | 229 | 110d | 55d | 1405/2/7 | 1405/2/16 |
| 231 | 4.1.14 | **UPS سیستم** | 37d | 2026-03-14 | 2026-04-24 |  | 132d |  | 1404/12/23 | 1405/2/4 |
| 232 | 4.1.14.1 | UPS استعلام قیمت سیستم | 10d | 2026-03-14 | 2026-03-28 | 152 | 132d | 0d | 1404/12/23 | 1405/1/8 |
| 233 | 4.1.14.2 | UPS خرید سیستم | 20d | 2026-03-29 | 2026-04-17 | 232 | 132d | 0d | 1405/1/9 | 1405/1/28 |
| 234 | 4.1.14.3 | UPS حمل سیستم | 7d | 2026-04-18 | 2026-04-24 | 233 | 132d | 119d | 1405/1/29 | 1405/2/4 |
| 235 | 4.1.15 | **سیستم اعلان حریق و تجهیزات جانبی** | 16d | 2026-03-10 | 2026-03-30 |  | 156d |  | 1404/12/19 | 1405/1/10 |
| 236 | 4.1.15.1 | استعلام قیمت سیستم اعلان حریق و تجهیزات جانبی | 2d | 2026-03-10 | 2026-03-11 | 164, 8, 161 | 156d | 0d | 1404/12/19 | 1404/12/20 |
| 237 | 4.1.15.2 | خرید سیستم اعلان حریق و تجهیزات جانبی | 7d | 2026-03-12 | 2026-03-18 | 236 | 156d | 0d | 1404/12/21 | 1404/12/27 |
| 238 | 4.1.15.3 | حمل سیستم اعلان حریق و تجهیزات جانبی | 7d | 2026-03-19 | 2026-03-30 | 237 | 156d | 42d | 1404/12/28 | 1405/1/10 |
| 239 | 4.1.16 | **سیستم اطفا حریق و تجهیزات جانبی** | 20d | 2026-03-17 | 2026-04-10 |  | 137d |  | 1404/12/26 | 1405/1/21 |
| 240 | 4.1.16.1 | استعلام قیمت سیستم اطفا حریق و تجهیزات جانبی | 3d | 2026-03-17 | 2026-03-19 | 161, 165, 8 | 137d | 0d | 1404/12/26 | 1404/12/28 |
| 241 | 4.1.16.2 | خرید سیستم اطفا حریق و تجهیزات جانبی | 10d | 2026-03-25 | 2026-04-03 | 240 | 137d | 0d | 1405/1/5 | 1405/1/14 |
| 242 | 4.1.16.3 | حمل سیستم اطفا حریق و تجهیزات جانبی | 7d | 2026-04-04 | 2026-04-10 | 241 | 137d | 41d | 1405/1/15 | 1405/1/21 |
| 243 | 4.1.17 | **سایر تجهیزات نیروگاه** | 98d | 2026-03-09 | 2026-06-19 |  | 85d |  | 1404/12/18 | 1405/3/29 |
| 244 | 4.1.17.1 | لوازم یدکی | 73d | 2026-04-08 | 2026-06-19 | 245, 171, 176 | 85d |  | 1405/1/19 | 1405/3/29 |
| 245 | 4.1.17.2 | ایستگاه هواشناسی و سنسورها | 25d | 2026-03-09 | 2026-04-07 | 171, 176 | 85d | 0d | 1404/12/18 | 1405/1/18 |
| 246 | 4.1.18 | **مصالح و تجهیز کارگاه** | 70d | 2026-01-27 | 2026-04-11 |  | 22d |  | 1404/11/7 | 1405/1/22 |
| 247 | 4.1.18.1 | مصالح ساختمانی و ملزومات عمرانی | 30d | 2026-03-08 | 2026-04-11 | 96, 78 | 23d | 0d | 1404/12/17 | 1405/1/22 |
| 248 | 4.1.18.2 | مصالح ،تجهیزات و ملزومات برقی ساختمان ها | 30d | 2026-03-08 | 2026-04-11 | 96 | 111d | 30d | 1404/12/17 | 1405/1/22 |
| 249 | 4.1.18.3 | تانک سپتیک و دو مخزن 10 هزار لیتری سه لایه | 5d | 2026-02-19 | 2026-02-23 | 101, 102 | 0d |  | 1404/11/30 | 1404/12/4 |
| 250 | 4.1.18.4 | کلیه تجهیزات و ملزومات اداری | 15d | 2026-03-08 | 2026-03-27 | 96 | 147d | 0d | 1404/12/17 | 1405/1/7 |
| 251 | 4.1.18.5 | سایر خرید تجهیز کارگاه | 15d | 2026-01-27 | 2026-02-10 | 6 | 22d |  | 1404/11/7 | 1404/11/21 |

| ID | WBS | Task | Duration | Start | Finish | Predecessors | Total slack | Free slack | start shamsi | finish shamsi |
| --- | --- | --- | --- | --- | --- | --- | --- | --- | --- | --- |
| 252 | 4.2 | **خرید خارجی، حمل بین المللی و ترخیص** | 170d | 2026-01-28 | 2026-07-21 |  | 18d |  | 1404/11/8 | 1405/4/30 |
| 253 | 4.2.1 | **خرید سازه های نگهدارنده پنل ها و اینورترها** | 82d | 2026-02-23 | 2026-05-20 |  | 0d |  | 1404/12/4 | 1405/2/30 |
| 254 | 4.2.1.1 | استعلام قیمتی و سفارش گذاری سازه های نگهدارنده | 5d | 2026-02-23 | 2026-02-27 | 92, 106 | 0d |  | 1404/12/4 | 1404/12/8 |
| 255 | 4.2.1.2 | ساخت سازه های نگهدارنده و بازرسی قبل حمل | 20d | 2026-02-28 | 2026-03-19 | 254 | 0d |  | 1404/12/9 | 1404/12/28 |
| 256 | 4.2.1.3 | حمل خارجی سازه های نگهدارنده | 35d | 2026-03-25 | 2026-04-28 | 255 | 0d |  | 1405/1/5 | 1405/2/8 |
| 257 | 4.2.1.4 | ترخیص سازه های نگهدارنده | 15d | 2026-04-29 | 2026-05-13 | 256 | 0d |  | 1405/2/9 | 1405/2/23 |
| 258 | 4.2.1.5 | حمل داخلی سازه های نگهدارنده و تحویل در سایت | 7d | 2026-05-14 | 2026-05-20 | 257 | 0d |  | 1405/2/24 | 1405/2/30 |
| 259 | 4.2.2 | **خرید پنل های خورشیدی** | 127d | 2026-01-28 | 2026-06-08 |  | 13d |  | 1404/11/8 | 1405/3/18 |
| 260 | 4.2.2.1 | استعلام قیمتی و ثبت سفارش پنل های خورشیدی | 5d | 2026-01-28 | 2026-02-01 | 21 | 39d | 26d | 1404/11/8 | 1404/11/12 |
| 261 | 4.2.2.2 | ساخت پنل های خورشیدی و بازرسی قبل حمل | 30d | 2026-02-28 | 2026-04-03 | 260, 9 | 13d | 0d | 1404/12/9 | 1405/1/14 |
| 262 | 4.2.2.3 | حمل خارجی پنل های خورشیدی | 45d | 2026-04-04 | 2026-05-18 | 261 | 13d | 0d | 1405/1/15 | 1405/2/28 |
| 263 | 4.2.2.4 | ترخیص پنل های خورشیدی | 14d | 2026-05-19 | 2026-06-01 | 262 | 13d | 0d | 1405/2/29 | 1405/3/11 |
| 264 | 4.2.2.5 | حمل داخلی پنل های خورشیدی و تحویل در سایت | 7d | 2026-06-02 | 2026-06-08 | 263 | 13d |  | 1405/3/12 | 1405/3/18 |
| 265 | 4.2.3 | **خرید اینورترهای خورشیدی** | 152d | 2026-02-15 | 2026-07-21 |  | 18d |  | 1404/11/26 | 1405/4/30 |
| 266 | 4.2.3.1 | استعلام قیمتی ثبت سفارش اینورترهای خورشیدی | 7d | 2026-02-15 | 2026-02-21 | 106, 22 | 19d | 6d | 1404/11/26 | 1404/12/2 |
| 267 | 4.2.3.2 | ساخت اینورترهای خورشیدی و بازرسی قبل حمل | 73d | 2026-02-28 | 2026-05-16 | 266, 9 | 18d | 0d | 1404/12/9 | 1405/2/26 |
| 268 | 4.2.3.3 | حمل خارجی اینورترهای خورشیدی | 45d | 2026-05-17 | 2026-06-30 | 267 | 18d | 0d | 1405/2/27 | 1405/4/9 |
| 269 | 4.2.3.4 | ترخیص اینورترهای خورشیدی | 14d | 2026-07-01 | 2026-07-14 | 268 | 18d | 0d | 1405/4/10 | 1405/4/23 |
| 270 | 4.2.3.5 | حمل داخلی اینورترهای خورشیدی و تحویل در سایت | 7d | 2026-07-15 | 2026-07-21 | 269 | 18d | 0d | 1405/4/24 | 1405/4/30 |
| 271 | 4.2.4 | **خرید MV Station** | 152d | 2026-02-15 | 2026-07-21 |  | 18d |  | 1404/11/26 | 1405/4/30 |
| 272 | 4.2.4.1 | استعلام قیمتی ثبت سفارش MV Station | 7d | 2026-02-15 | 2026-02-21 | 106, 23 | 19d | 6d | 1404/11/26 | 1404/12/2 |
| 273 | 4.2.4.2 | ساخت MV Station و بازرسی قبل حمل | 73d | 2026-02-28 | 2026-05-16 | 272, 9 | 18d | 0d | 1404/12/9 | 1405/2/26 |
| 274 | 4.2.4.3 | حمل خارجی MV Station | 45d | 2026-05-17 | 2026-06-30 | 273 | 18d | 0d | 1405/2/27 | 1405/4/9 |
| 275 | 4.2.4.4 | ترخیص MV Station | 14d | 2026-07-01 | 2026-07-14 | 274 | 18d | 0d | 1405/4/10 | 1405/4/23 |
| 276 | 4.2.4.5 | حمل داخلی MV Station و تحویل در سایت | 7d | 2026-07-15 | 2026-07-21 | 275 | 18d | 0d | 1405/4/24 | 1405/4/30 |

Notes:
- 259: باراندازی کلی
- 261: 28 سنت یرو

| ID | WBS | Task | Duration | Start | Finish | Predecessors | Total slack | Free slack | start shamsi | finish shamsi |
| --- | --- | --- | --- | --- | --- | --- | --- | --- | --- | --- |
| 277 | 5 | **عملیات اجرایی** | 204d | 2026-02-10 | 2026-09-06 |  | 6d |  | 1404/11/21 | 1405/6/15 |
| 278 | 5.1 | **تجهیز کارگاه** | 14d | 2026-02-24 | 2026-03-09 |  | 0d |  | 1404/12/5 | 1404/12/18 |
| 279 | 5.1.1 | تانک سپتیک و دو مخزن 10 هزار لیتری سه لایه | 6d | 2026-02-24 | 2026-03-01 | 6, 249 | 0d |  | 1404/12/5 | 1404/12/10 |
| 280 | 5.1.2 | کانکس نگهبانی | 3d | 2026-03-02 | 2026-03-04 | 279, 6 | 0d |  | 1404/12/11 | 1404/12/13 |
| 281 | 5.1.3 | سایر تجهیز کارگاه | 5d | 2026-03-05 | 2026-03-09 | 280, 6, 251, 74 | 0d |  | 1404/12/14 | 1404/12/18 |
| 282 | 5.2 | **اجرای جاده دسترسی تا جاده اصلی** | 8d | 2026-02-10 | 2026-02-17 |  | 20d |  | 1404/11/21 | 1404/11/28 |
| 283 | 5.2.1 | زیرسازی | 6d | 2026-02-10 | 2026-02-15 | 86, 87 | 20d | 0d | 1404/11/21 | 1404/11/26 |
| 284 | 5.2.2 | شن ریزی | 2d | 2026-02-16 | 2026-02-17 | 283 | 20d |  | 1404/11/27 | 1404/11/28 |
| 285 | 5.3 | **عملیات عمرانی** | 174d | 2026-03-10 | 2026-09-04 |  | 0d |  | 1404/12/19 | 1405/6/13 |
| 286 | 5.3.1 | **عملیات دسترسی و آماده سازی سایت** | 85d | 2026-03-10 | 2026-06-07 |  | 0d |  | 1404/12/19 | 1405/3/17 |
| 287 | 5.3.1.1 | تسطیح و تحکیم زمین | 20d | 2026-03-10 | 2026-04-03 | 83, 280, 8, 281, 11, 284 | 0d |  | 1404/12/19 | 1405/1/14 |
| 288 | 5.3.1.2 | اجرای گیت ورودی | 15d | 2026-05-13 | 2026-05-27 | 78, 293, 247FS-5d | 0d |  | 1405/2/23 | 1405/3/6 |
| 289 | 5.3.1.3 | احداث پارکینگ مسقف | 7d | 2026-06-01 | 2026-06-07 | 77, 79, 319 | 97d |  | 1405/3/11 | 1405/3/17 |
| 290 | 5.3.2 | اجرای سیستم زهکشی | 40d | 2026-04-04 | 2026-05-13 | 72, 84, 287 | 85d | 38d | 1405/1/15 | 1405/2/23 |
| 291 | 5.3.3 | **اجرای فنس پیرامونی** | 39d | 2026-04-04 | 2026-05-12 |  | 0d |  | 1405/1/15 | 1405/2/22 |
| 292 | 5.3.3.1 | اجرای فونداسیون و پایه فنس | 24d | 2026-04-04 | 2026-04-27 | 82, 279, 287, 104, 182 | 0d |  | 1405/1/15 | 1405/2/7 |
| 293 | 5.3.3.2 | اجرای فنس | 35d | 2026-04-08 | 2026-05-12 | 292SS+4d | 0d |  | 1405/1/19 | 1405/2/22 |
| 294 | 5.3.4 | **اجرای فونداسیون MV Station** | 33d | 2026-06-18 | 2026-07-20 |  | 42d |  | 1405/3/28 | 1405/4/29 |
| 295 | 5.3.4.1 | گودبرداری فونداسیون | 3d | 2026-06-18 | 2026-06-20 | 89, 306 | 42d | 0d | 1405/3/28 | 1405/3/30 |
| 296 | 5.3.4.2 | بتن ریزی فونداسیون | 30d | 2026-06-21 | 2026-07-20 | 295 | 42d | 1d | 1405/3/31 | 1405/4/29 |
| 297 | 5.3.5 | **ساختمان پست سوییچگیر** | 118d | 2026-04-12 | 2026-08-07 |  | 23d |  | 1405/1/23 | 1405/5/16 |
| 298 | 5.3.5.1 | اجرای فونداسیون ساختمان پست سوییچگیر | 28d | 2026-04-12 | 2026-05-09 | 76, 72, 83, 85, 157, 279, 247 | 23d | 0d | 1405/1/23 | 1405/2/19 |
| 299 | 5.3.5.2 | سفت کاری ساختمان پست سوییچگیر | 60d | 2026-05-10 | 2026-07-08 | 298 | 23d | 0d | 1405/2/20 | 1405/4/17 |
| 300 | 5.3.5.3 | اجرای تاسیسات ساختمان پست سوییچگیر | 10d | 2026-07-09 | 2026-07-18 | 299, 248 | 23d | 0d | 1405/4/18 | 1405/4/27 |
| 301 | 5.3.5.4 | نازک کاری ساختمان پست سوییچگیر | 10d | 2026-07-19 | 2026-07-28 | 300 | 23d | 0d | 1405/4/28 | 1405/5/6 |
| 302 | 5.3.5.5 | اجرای نمای ساختمان پست سوییچگیر | 10d | 2026-07-29 | 2026-08-07 | 301 | 23d | 0d | 1405/5/7 | 1405/5/16 |
| 303 | 5.3.5.6 | اجرای سیستم اعلام حریق ساختمان پست سوییچگیر | 5d | 2026-07-09 | 2026-07-13 | 299, 238 | 56d | 29d | 1405/4/18 | 1405/4/22 |
| 304 | 5.3.5.7 | اجرای سیستم اطفا حریق ساختمان پست سوییچگیر | 5d | 2026-07-19 | 2026-07-23 | 300, 242 | 38d | 15d | 1405/4/28 | 1405/5/1 |

Notes:
- 290: پیانکار سفت کاری ساختمان در زمان دیار چیی استارت ای عملیت را نی می تواند بزند.بدلی عدم مناسب بودن اجرا در روزهای ابتدایی بدلی تردد ماشی آلات و موارد دیر که موجب بار آمدن خرابی کانال میود.

| ID | WBS | Task | Duration | Start | Finish | Predecessors | Total slack | Free slack | start shamsi | finish shamsi |
| --- | --- | --- | --- | --- | --- | --- | --- | --- | --- | --- |
| 305 | 5.3.6 | **ساختمان مانیتورینگ** | 161d | 2026-03-28 | 2026-09-04 |  | 3d |  | 1405/1/8 | 1405/6/13 |
| 306 | 5.3.6.1 | اجرای فونداسیون ساختمان مانیتورینگ | 21d | 2026-05-28 | 2026-06-17 | 76FS-6d, 72, 83, 85, 157, 279, 288, 247 | 0d |  | 1405/3/7 | 1405/3/27 |
| 307 | 5.3.6.2 | سفت کاری ساختمان مانیتورینگ | 50d | 2026-06-18 | 2026-08-06 | 306 | 0d |  | 1405/3/28 | 1405/5/15 |
| 308 | 5.3.6.3 | اجرای تاسیسات ساختمان مانیتورینگ | 10d | 2026-08-07 | 2026-08-16 | 307 | 0d |  | 1405/5/16 | 1405/5/25 |
| 309 | 5.3.6.4 | نازک کاری ساختمان مانیتورینگ | 10d | 2026-08-17 | 2026-08-26 | 308 | 0d |  | 1405/5/26 | 1405/6/4 |
| 310 | 5.3.6.5 | اجرای نمای ساختمان مانیتورینگ | 9d | 2026-08-27 | 2026-09-04 | 309, 313 | 0d |  | 1405/6/5 | 1405/6/13 |
| 311 | 5.3.6.6 | اجرای سیستم اعلام حریق ساختمان مانیتورینگ | 5d | 2026-08-07 | 2026-08-11 | 307, 238 | 27d | 0d | 1405/5/16 | 1405/5/20 |
| 312 | 5.3.6.7 | اجرای سیستم اطفا حریق ساختمان مانیتورینگ | 5d | 2026-08-17 | 2026-08-21 | 308, 242 | 13d | 0d | 1405/5/26 | 1405/5/30 |
| 313 | 5.3.6.8 | کلیه تجهیزات و ملزومات | 5d | 2026-03-28 | 2026-04-01 | 74, 250 | 147d |  | 1405/1/8 | 1405/1/12 |
| 314 | 5.3.7 | **ساختمان نگهبانی** | 50d | 2026-04-12 | 2026-05-31 |  | 97d |  | 1405/1/23 | 1405/3/10 |
| 315 | 5.3.7.1 | اجرای فونداسیون ساختمان نگهبانی | 10d | 2026-04-12 | 2026-04-21 | 76, 72, 83, 85, 157, 279, 247 | 97d | 0d | 1405/1/23 | 1405/2/1 |
| 316 | 5.3.7.2 | سفت کاری ساختمان نگهبانی | 20d | 2026-04-22 | 2026-05-11 | 315 | 97d | 0d | 1405/2/2 | 1405/2/21 |
| 317 | 5.3.7.3 | اجرای تاسیسات ساختمان نگهبانی | 10d | 2026-05-12 | 2026-05-21 | 316, 248 | 97d | 0d | 1405/2/22 | 1405/2/31 |
| 318 | 5.3.7.4 | نازک کاری ساختمان نگهبانی | 5d | 2026-05-22 | 2026-05-26 | 317 | 97d | 0d | 1405/3/1 | 1405/3/5 |
| 319 | 5.3.7.5 | اجرای نمای ساختمان نگهبانی | 5d | 2026-05-27 | 2026-05-31 | 318 | 97d | 0d | 1405/3/6 | 1405/3/10 |
| 320 | 5.3.7.6 | اجرای سیستم اعلام حریق ساختمان نگهبانی | 2d | 2026-05-12 | 2026-05-13 | 316, 238 | 117d | 90d | 1405/2/22 | 1405/2/23 |
| 321 | 5.3.7.7 | اجرای سیستم اطفا حریق ساختمان نگهبانی | 2d | 2026-05-22 | 2026-05-23 | 317, 242 | 107d | 90d | 1405/3/1 | 1405/3/2 |
| 322 | 5.4 | **عملیات مکانیکال** | 140d | 2026-04-04 | 2026-08-21 |  | 0d |  | 1405/1/15 | 1405/5/30 |
| 323 | 5.4.1 | نقشه برداری پایه ها و میخ کوبی | 6d | 2026-04-04 | 2026-04-09 | 65, 83, 95, 287 | 41d |  | 1405/1/15 | 1405/1/20 |
| 324 | 5.4.2 | پایه کوبی | 46d | 2026-05-21 | 2026-07-05 | 323, 258 | 0d |  | 1405/2/31 | 1405/4/14 |
| 325 | 5.4.3 | نصب متعلقات استراکچرها | 56d | 2026-05-25 | 2026-07-19 | 324SS+4d, 94 | 0d |  | 1405/3/4 | 1405/4/28 |
| 326 | 5.4.4 | نصب پنل ها | 61d | 2026-06-22 | 2026-08-21 | 325FS-5%, 264 | 0d |  | 1405/4/1 | 1405/5/30 |
| 327 | 5.5 | **عملیات الکتریکال** | 78d | 2026-06-21 | 2026-09-06 |  | 1d |  | 1405/3/31 | 1405/6/15 |
| 328 | 5.5.1 | اجرای ترانشه و کانال عبور فیبر نوری | 10d | 2026-06-21 | 2026-06-30 | 324FS-15d, 119, 118, 290 | 47d | 0d | 1405/3/31 | 1405/4/9 |
| 329 | 5.5.2 | نصب سازه اینورتر و وایرینگ اینورترهای سایت | 8d | 2026-07-22 | 2026-07-29 | 270, 258, 10 | 18d | 0d | 1405/4/31 | 1405/5/7 |
| 330 | 5.5.3 | اجرای سیستم زمین نیروگاه | 15d | 2026-07-01 | 2026-07-15 | 328, 121, 218 | 47d | 0d | 1405/4/10 | 1405/4/24 |
| 331 | 5.5.4 | تابلوهای فشار متوسط و کلیه متعلقات | 5d | 2026-08-08 | 2026-08-12 | 302, 304, 194 | 23d | 0d | 1405/5/17 | 1405/5/21 |
| 332 | 5.5.5 | تابلوهای فشار ضعیف و کلیه متعلقات | 2d | 2026-08-08 | 2026-08-09 | 130, 302, 186, 198 | 28d | 0d | 1405/5/17 | 1405/5/18 |
| 333 | 5.5.6 | کلیه کابل های فشار ضعیف نیروگاهac | 15d | 2026-07-30 | 2026-08-13 | 328, 114, 118, 329, 16, 202 | 18d | 0d | 1405/5/8 | 1405/5/22 |
| 334 | 5.5.7 | کلیه کابل های فشار متوسط نیروگاهac | 6d | 2026-07-06 | 2026-07-11 | 328FS+5d, 118, 65, 202 | 51d | 0d | 1405/4/15 | 1405/4/20 |
| 335 | 5.5.8 | کابل dc | 14d | 2026-08-22 | 2026-09-04 | 326, 325FS-10d, 12FS-10d, 13FS-10d, 206 | 0d |  | 1405/5/31 | 1405/6/13 |
| 336 | 5.5.9 | اجرای کابل های فیبر نوری | 3d | 2026-07-01 | 2026-07-03 | 328, 214 | 58d | 0d | 1405/4/10 | 1405/4/12 |
| 337 | 5.5.10 | نصب ایستگاه هواشناسی و سنسورها | 3d | 2026-07-24 | 2026-07-26 | 338, 245 | 41d | 40d | 1405/5/2 | 1405/5/4 |
| 338 | 5.5.11 | MV Station نصب | 2d | 2026-07-22 | 2026-07-23 | 296, 276, 10 | 41d | 0d | 1405/4/31 | 1405/5/1 |
| 339 | 5.5.12 | اجرای کلیه ملزومات و تجهیزات مربوط به ایجاد شبکه انتقال دیتا و بستر مخابراتی با پست بالادست به جز فیبر نوری | 3d | 2026-07-09 | 2026-07-11 | 336FS+5d, 210 | 58d | 0d | 1405/4/18 | 1405/4/20 |
| 340 | 5.5.13 | نصب ترانسفورماتور کمکی و دیزل | 1d | 2026-09-05 | 2026-09-05 | 312, 310, 90, 14, 190 | 0d |  | 1405/6/14 | 1405/6/14 |
| 341 | 5.5.14 | نصب یو پی اس | 1d | 2026-08-22 | 2026-08-22 | 312, 302, 234 | 13d | 0d | 1405/5/31 | 1405/5/31 |
| 342 | 5.5.15 | سیستم حفاظت صاعقه | 2d | 2026-07-18 | 2026-07-19 | 125, 364, 218 | 47d | 0d | 1405/4/27 | 1405/4/28 |
| 343 | 5.5.16 | اجرای کلیه ملزومات و تجهیزات مربوط به ایجاد شبکه انتقال دیتا و ارسال دیتا | 2d | 2026-09-05 | 2026-09-06 | 336, 302, 310, 337, 15, 214, 210 | 1d | 0d | 1405/6/14 | 1405/6/15 |

Notes:
- 328: پیانکار جدا دارد
- 329: هزیه ارتیگش هم ایجا دیه شده
- 330: اجرای برق گی و صاعقه گی رو هم با سیتم ارت دیم
- 335: به همراه سوکت زنی mc4
- 337: قبل مانیوریگ بای نصب و راه اندازی بشه
- 339: ای همون اسکادا هست که کار جمع آوری دیا رو انجام میه / کابل های دیا که تموم شد میه کارای راه اندازیم انجام دد و تستش کرد
- 343: اسکادا رو همپوشانی با خط انتقال انجام بده اما آر تی ی بای بعد اجرای بستر ارتباطی اجرا و نهایی بشه / هماهنگی های زیدی داره / اسکادا جمع آوری اطلاعات داخل سایه،آر تی ی برای انتقال دیای جمع آوری شده تویط اسکادا به سایه

| ID | WBS | Task | Duration | Start | Finish | Predecessors | Total slack | Free slack | start shamsi | finish shamsi |
| --- | --- | --- | --- | --- | --- | --- | --- | --- | --- | --- |
| 344 | 5.5.17 | **کلیه متعلقات مربوط به کابل کشی و سیم کشی** | 46d | 2026-07-12 | 2026-08-26 |  | 8d |  | 1405/4/21 | 1405/6/4 |
| 345 | 5.5.17.1 | نصب لدر | 3d | 2026-08-08 | 2026-08-10 | 302, 334 | 24d | 16d | 1405/5/17 | 1405/5/19 |
| 346 | 5.5.17.2 | اجرای لوله پلی اتیلن و فلکسی | 5d | 2026-08-22 | 2026-08-26 | 335SS, 325, 222 | 8d | 0d | 1405/5/31 | 1405/6/4 |
| 347 | 5.5.17.3 | اجرای سرسیم و کابل شو | 3d | 2026-08-14 | 2026-08-16 | 333 | 18d | 10d | 1405/5/23 | 1405/5/25 |
| 348 | 5.5.17.4 | اجرای سر کابل | 2d | 2026-07-12 | 2026-07-13 | 334 | 52d | 44d | 1405/4/21 | 1405/4/22 |
| 349 | 5.5.18 | **نصب سیستم روشنایی** | 14d | 2026-07-01 | 2026-07-14 |  | 55d |  | 1405/4/10 | 1405/4/23 |
| 350 | 5.5.18.1 | اجرای فونداسیون سیستم روشنایی | 8d | 2026-07-01 | 2026-07-08 | 137, 293, 328, 230, 151 | 55d | 0d | 1405/4/10 | 1405/4/17 |
| 351 | 5.5.18.2 | کابل کشی سیستم روشنایی | 5d | 2026-07-01 | 2026-07-05 | 118, 328 | 64d | 9d | 1405/4/10 | 1405/4/14 |
| 352 | 5.5.18.3 | نصب پایه ها و چراغ ها | 6d | 2026-07-09 | 2026-07-14 | 350 | 55d | 0d | 1405/4/18 | 1405/4/23 |
| 353 | 5.5.19 | **CCTV نصب سیستم** | 9d | 2026-07-01 | 2026-07-09 |  | 59d |  | 1405/4/10 | 1405/4/18 |
| 354 | 5.5.19.1 | اجرای فونداسیون دوربین | 5d | 2026-07-01 | 2026-07-05 | 169, 170, 279, 328, 226 | 59d | 0d | 1405/4/10 | 1405/4/14 |
| 355 | 5.5.19.2 | کابل کشی دوربین ها | 5d | 2026-07-01 | 2026-07-05 | 118, 328 | 63d | 4d | 1405/4/10 | 1405/4/14 |
| 356 | 5.5.19.3 | نصب پایه ها و چراغ ها | 4d | 2026-07-06 | 2026-07-09 | 354 | 59d | 0d | 1405/4/15 | 1405/4/18 |
| 357 | 6 | **تست و تحویل** | 172d | 2026-03-25 | 2026-09-12 |  | 0d |  | 1405/1/5 | 1405/6/21 |
| 358 | 6.1 | **تست و راه اندازی نیروگاه** | 172d | 2026-03-25 | 2026-09-12 |  | 0d |  | 1405/1/5 | 1405/6/21 |
| 359 | 6.1.1 | تست کلیه کابل های فشار ضعیف نیروگاهac | 2d | 2026-08-14 | 2026-08-15 | 333 | 24d |  | 1405/5/23 | 1405/5/24 |
| 360 | 6.1.2 | تست کلیه کابل های فشار متوسط نیروگاهac | 2d | 2026-07-12 | 2026-07-13 | 334 | 57d |  | 1405/4/21 | 1405/4/22 |
| 361 | 6.1.3 | تست کابل dc | 4d | 2026-09-05 | 2026-09-08 | 335 | 0d |  | 1405/6/14 | 1405/6/17 |
| 362 | 6.1.4 | تست تابلوهای فشار متوسط و کلیه متعلقات | 1d | 2026-08-13 | 2026-08-13 | 331 | 23d | 0d | 1405/5/22 | 1405/5/22 |
| 363 | 6.1.5 | تست کابل شبکه مورد نیازسیستم انتقال دیتا و اسکادا | 1d | 2026-07-04 | 2026-07-04 | 336 | 64d | 0d | 1405/4/13 | 1405/4/13 |
| 364 | 6.1.6 | تست سیستم زمین نیروگاه | 2d | 2026-07-16 | 2026-07-17 | 330 | 47d | 0d | 1405/4/25 | 1405/4/26 |
| 365 | 6.1.7 | تست کلیه متعلقات مربوط به کابل کشی و سیم کشی | 2d | 2026-08-27 | 2026-08-28 | 345, 346, 347, 348 | 8d | 0d | 1405/6/5 | 1405/6/6 |
| 366 | 6.1.8 | تست تابلوهای فشار ضعیف و کلیه متعلقات | 2d | 2026-08-10 | 2026-08-11 | 332 | 28d |  | 1405/5/19 | 1405/5/20 |
| 367 | 6.1.9 | تست کلیه ملزومات و تجهیزات مربوط به ایجاد شبکه انتقال دیتا و بستر مخابراتی با پست بالادست | 1d | 2026-07-12 | 2026-07-12 | 339 | 58d | 0d | 1405/4/21 | 1405/4/21 |
| 368 | 6.1.10 | تست کلیه ملزومات و تجهیزات مربوط به ایجاد شبکه انتقال دیتا و ارسال دیتا | 1d | 2026-09-07 | 2026-09-07 | 343 | 1d |  | 1405/6/16 | 1405/6/16 |
| 369 | 6.1.11 | تست یو پی اس | 1d | 2026-08-23 | 2026-08-23 | 341 | 13d | 0d | 1405/6/1 | 1405/6/1 |
| 370 | 6.1.12 | تست کلیه تجهیزات مربوط به دوربین | 2d | 2026-07-10 | 2026-07-11 | 355, 356 | 59d |  | 1405/4/19 | 1405/4/20 |
| 371 | 6.1.13 | تست سیستم روشنایی | 1d | 2026-07-15 | 2026-07-15 | 351, 352 | 55d |  | 1405/4/24 | 1405/4/24 |
| 372 | 6.1.14 | تست سیستم اعلام حریق | 1d | 2026-08-12 | 2026-08-12 | 303, 311, 320 | 27d |  | 1405/5/21 | 1405/5/21 |
| 373 | 6.1.15 | تست سیستم اطفا حریق | 1d | 2026-08-22 | 2026-08-22 | 304, 312, 321 | 17d |  | 1405/5/31 | 1405/5/31 |
| 374 | 6.1.16 | تست سیستم حفاظت صاعقه | 1d | 2026-07-20 | 2026-07-20 | 342 | 47d | 0d | 1405/4/29 | 1405/4/29 |
| 375 | 6.1.17 | تست ترانسفورماتور کمکی و دیزل | 1d | 2026-09-06 | 2026-09-06 | 340 | 0d |  | 1405/6/15 | 1405/6/15 |

| ID | WBS | Task | Type | Duration | Start | Finish | Predecessors | Total slack | start shamsi | finish shamsi |
| --- | --- | --- | --- | --- | --- | --- | --- | --- | --- | --- |
| 376 | 6.1.18 | **ارایه نقشه های ازبیلت** |  | 22d | 2026-08-22 | 2026-09-12 |  | 0d | 1405/5/31 | 1405/6/21 |
| 377 | 6.1.18.1 | ارایه نقشه های ازبیلت الکتریکال |  | 4d | 2026-09-09 | 2026-09-12 | 359, 360, 361, 362, 363, 364, 365, 366, 367, 368, 369, 370, 371, 372, 373, 374, 375, 17 | 0d | 1405/6/18 | 1405/6/21 |
| 378 | 6.1.18.2 | ارایه نقشه های ازبیلت مکانیکال |  | 7d | 2026-08-22 | 2026-08-28 | 326, 12 | 15d | 1405/5/31 | 1405/6/6 |
| 379 | 6.1.18.3 | ارایه نقشه های ازبیلت civil |  | 7d | 2026-09-05 | 2026-09-11 | 302, 310, 319, 296 | 1d | 1405/6/14 | 1405/6/20 |
| 380 | 6.1.19 | **مستندات حوزه کیفیت مطابق MDL ارایه شده** |  | 168d | 2026-03-25 | 2026-09-08 |  | 0d | 1405/1/5 | 1405/6/17 |
| 381 | 6.1.19.1 | Solar Panel Installation Manual & Operation & Maintenance |  | 1d | 2026-04-04 | 2026-04-04 | 261 | 156d | 1405/1/15 | 1405/1/15 |
| 382 | 6.1.19.2 | Inverter Installation Manual & Operation & Maintenance |  | 1d | 2026-05-17 | 2026-05-17 | 267 | 113d | 1405/2/27 | 1405/2/27 |
| 383 | 6.1.19.3 | MV Station Installation Manual & Operation & Maintenance |  | 1d | 2026-05-17 | 2026-05-17 | 273 | 113d | 1405/2/27 | 1405/2/27 |
| 384 | 6.1.19.4 | UPS Installation Manual & Operation & Maintenance |  | 1d | 2026-04-18 | 2026-04-18 | 233 | 142d | 1405/1/29 | 1405/1/29 |
| 385 | 6.1.19.5 | AUX Transformer Installation Manual & Operation & Maintenance |  | 1d | 2026-04-06 | 2026-04-06 | 189 | 154d | 1405/1/17 | 1405/1/17 |
| 386 | 6.1.19.6 | Diesel Generator Installation Manual & Operation & Maintenance |  | 1d | 2026-04-06 | 2026-04-06 | 189 | 154d | 1405/1/17 | 1405/1/17 |
| 387 | 6.1.19.7 | Weather Station Installation Manual & Operation & Maintenance |  | 1d | 2026-04-08 | 2026-04-08 | 245 | 152d | 1405/1/19 | 1405/1/19 |
| 388 | 6.1.19.8 | Solar Structure Installation Manual & Operation & Maintenance |  | 1d | 2026-03-25 | 2026-03-25 | 255 | 166d | 1405/1/5 | 1405/1/5 |
| 389 | 6.1.19.9 | SCADA and Monitoring System Installation Manual & Operation & Maintenance |  | 1d | 2026-07-05 | 2026-07-05 | 363 | 64d | 1405/4/14 | 1405/4/14 |
| 390 | 6.1.19.10 | Project O&M General Instructions |  | 1d | 2026-05-17 | 2026-05-17 | 233, 255, 261, 267, 273 | 113d | 1405/2/27 | 1405/2/27 |
| 391 | 6.1.19.11 | Test Report of Solar Structure |  | 2d | 2026-03-25 | 2026-03-26 | 255 | 165d | 1405/1/5 | 1405/1/6 |
| 392 | 6.1.19.12 | Test Reports for PV Modules |  | 2d | 2026-04-04 | 2026-04-05 | 261 | 155d | 1405/1/15 | 1405/1/16 |
| 393 | 6.1.19.13 | Test Reports for Inverter |  | 2d | 2026-05-17 | 2026-05-18 | 267 | 112d | 1405/2/27 | 1405/2/28 |
| 394 | 6.1.19.14 | Test Reports for MV Sation |  | 2d | 2026-05-17 | 2026-05-18 | 273 | 112d | 1405/2/27 | 1405/2/28 |
| 395 | 6.1.19.15 | Test Reports for AC and DC Cables |  | 2d | 2026-08-29 | 2026-08-30 | 365 | 8d | 1405/6/7 | 1405/6/8 |
| 396 | 6.1.19.16 | Test Reports for Diesel Generators |  | 1d | 2026-09-07 | 2026-09-07 | 375 | 0d | 1405/6/16 | 1405/6/16 |
| 397 | 6.1.19.17 | Test Reports for AUX Transformer |  | 1d | 2026-09-07 | 2026-09-07 | 375 | 0d | 1405/6/16 | 1405/6/16 |
| 398 | 6.1.19.18 | Test Reports for Earthing and Ligthtning |  | 2d | 2026-07-21 | 2026-07-22 | 364, 374 | 47d | 1405/4/30 | 1405/4/31 |
| 399 | 6.1.19.19 | Test Reports for MV Switchgear (CT, PT, Relay, …) |  | 2d | 2026-08-14 | 2026-08-15 | 362 | 23d | 1405/5/23 | 1405/5/24 |
| 400 | 6.1.19.20 | Test Reports for UPS and Battery |  | 2d | 2026-08-24 | 2026-08-25 | 369 | 13d | 1405/6/2 | 1405/6/3 |
| 401 | 6.1.19.21 | کدگذاری و تحویل مستندات پروژه |  | 1d | 2026-09-08 | 2026-09-08 | 381, 382, 383, 384, 385, 386, 387, 388, 389, 390, 391, 392, 393, 394, 395, 396, 397, 398, 399, 400 | 0d | 1405/6/17 | 1405/6/17 |
| 402 | 6.2 | راه اندازی، اتصال به شبکه و پلمپ کنتور |  | 1d | 2026-09-09 | 2026-09-09 | 359, 360, 361, 362, 363, 364, 365, 366, 367, 368, 369, 370, 371, 372, 373, 374, 375, 279 | 0d | 1405/6/18 | 1405/6/18 |
| 403 | 6.3 | آموزش |  | 6d | 2026-09-07 | 2026-09-12 | 402FS-3d, 154 | 0d | 1405/6/16 | 1405/6/21 |
| 404 | 6.4 | برچیدن کارگاه |  | 4d | 2026-09-09 | 2026-09-12 | 402FS-3d, 401 | 0d | 1405/6/18 | 1405/6/21 |
| 405 | 7 | پایان | milestone | 0d | 2026-09-12 | 2026-09-12 | 402, 403, 404, 377, 378, 379, 289, 244, 140 | 0d | 1405/6/21 | 1405/6/21 |
